# Planejamento Obra

Schedule from MS Project, 2020-06-29 to 2021-05-18.

## Calendars

- Padrão: Mon-Fri 08:00-12:00, 13:00-17:00; Sat-Sun off.
- 24 Horas: Mon-Sun 00:00-24:00.

## Schedule

| ID | WBS | Task | Type | Duration | Start | Finish | Predecessors | Total slack | Free slack | Constraint | Calendar |
| --- | --- | --- | --- | --- | --- | --- | --- | --- | --- | --- | --- |
| 1 | 1 | **Substituição das Unidades de Amarração do Berço 106** |  | 231.12d | 2020-06-29 | 2021-05-18 |  | 0d |  |  |  |
| 2 | 1.1 | **Projetos** |  | 42d | 2020-06-29 | 2020-08-25 |  | 0d |  |  |  |
| 3 | 1.1.1 | Desenvolvimento do Projeto |  | 22d | 2020-06-29 | 2020-07-28 |  | 0d |  | start no earlier than 2020-06-29 |  |
| 4 | 1.1.2 | Análise EMAP |  | 10d | 2020-07-29 | 2020-08-11 | 3 | 0d |  |  |  |
| 5 | 1.1.3 | Correção e reapresentação do projeto |  | 5d | 2020-08-12 | 2020-08-18 | 4 | 0d |  |  |  |
| 6 | 1.1.4 | Reanálise e aprovação |  | 5d | 2020-08-19 | 2020-08-25 | 5 | 0d |  |  |  |
| 7 | 1.2 | **Fornecimento** |  | 130d | 2020-08-26 | 2021-02-23 |  | 0d |  |  |  |
| 8 | 1.2.1 | Fabricação |  | 130d | 2020-08-26 | 2021-02-23 | 6 | 0d |  |  |  |
| 9 | 1.2.2 | Entrega | milestone | 0d | 2021-02-23 | 2021-02-23 | 8 | 0d |  |  |  |
| 10 | 1.3 | **Preparação** |  | 93d | 2020-09-23 | 2021-02-01 |  | 0d |  |  |  |
| 11 | 1.3.1 | Documentação e proapi |  | 10d | 2020-09-23 | 2020-10-06 | 6FS+20d | 43d | 0d |  |  |
| 12 | 1.3.2 | Preparativos (ferramentas) |  | 40d | 2020-10-07 | 2020-12-01 | 11 | 43d |  |  |  |
| 13 | 1.3.3 | Planejamento e programação de janela junto à GELOG |  | 60d | 2020-10-28 | 2021-01-19 | 6FS+45d | 8d |  |  |  |
| 14 | 1.3.4 | O.S. p/ instalação | milestone | 0d | 2021-02-01 | 2021-02-01 | 12, 13, 9FS-17d | 0d |  |  |  |
| 15 | 1.4 | **Obras** |  | 55d | 2021-02-01 | 2021-04-18 |  | 0d |  |  |  |
| 16 | 1.4.1 | **Pré-instalação (elétrica)** |  | 25d | 2021-02-01 | 2021-03-05 |  | 0d |  |  |  |
| 17 | 1.4.1.1 | canteiro |  | 5d | 2021-02-01 | 2021-02-05 | 14 | 0d |  |  |  |
| 18 | 1.4.1.2 | elétrico |  | 20d | 2021-02-08 | 2021-03-05 | 17 | 0d |  |  |  |
| 19 | 1.4.2 | **Retirada e Instalação das Uas** |  | 30d | 2021-03-05 | 2021-04-18 |  | 0d |  |  |  |
| 20 | 1.4.2.1 | Desmontagem 1 |  | 48h | 2021-03-05 | 2021-03-07 | 18, 9 | 0d |  |  | 24 Horas |
| 21 | 1.4.2.2 | montagem 1 |  | 72h | 2021-03-07 | 2021-03-10 | 20 | 0d |  |  | 24 Horas |
| 22 | 1.4.2.3 | Testes e liberação 1 |  | 24h | 2021-03-10 | 2021-03-11 | 21 | 0d |  |  | 24 Horas |
| 23 | 1.4.2.4 | Desmontagem 2 |  | 48h | 2021-03-11 | 2021-03-13 | 22 | 0d |  |  | 24 Horas |
| 24 | 1.4.2.5 | montagem 2 |  | 72h | 2021-03-13 | 2021-03-16 | 23 | 0d |  |  | 24 Horas |
| 25 | 1.4.2.6 | Testes e liberação 2 |  | 24h | 2021-03-16 | 2021-03-17 | 24 | 0d |  |  | 24 Horas |
| 26 | 1.4.2.7 | Desmontagem 3 |  | 48h | 2021-03-17 | 2021-03-19 | 25 | 0d |  |  | 24 Horas |
| 27 | 1.4.2.8 | montagem 3 |  | 72h | 2021-03-19 | 2021-03-22 | 26 | 0d |  |  | 24 Horas |
| 28 | 1.4.2.9 | Testes e liberação 3 |  | 24h | 2021-03-22 | 2021-03-23 | 27 | 0d |  |  | 24 Horas |
| 29 | 1.4.2.10 | Desmontagem 4 |  | 48h | 2021-03-25 | 2021-03-27 | 28FS+5d | 0d |  |  | 24 Horas |
| 30 | 1.4.2.11 | montagem 4 |  | 72h | 2021-03-27 | 2021-03-30 | 29 | 144d | 0d |  | 24 Horas |
| 31 | 1.4.2.12 | Testes e liberação 4 |  | 24h | 2021-03-30 | 2021-03-31 | 30 | 144d |  |  | 24 Horas |
| 32 | 1.4.2.13 | Desmontagem 5 |  | 48h | 2021-03-25 | 2021-03-27 | 29SS | 0d |  |  | 24 Horas |
| 33 | 1.4.2.14 | montagem 5 |  | 72h | 2021-03-27 | 2021-03-30 | 32 | 0d |  |  | 24 Horas |
| 34 | 1.4.2.15 | Testes e liberação 5 |  | 24h | 2021-03-30 | 2021-03-31 | 33 | 0d |  |  | 24 Horas |
| 35 | 1.4.2.16 | Desmontagem 6 |  | 48h | 2021-03-31 | 2021-04-02 | 34 | 0d |  |  | 24 Horas |
| 36 | 1.4.2.17 | montagem 6 |  | 72h | 2021-04-02 | 2021-04-05 | 35 | 0d |  |  | 24 Horas |
| 37 | 1.4.2.18 | Testes e liberação 6 |  | 24h | 2021-04-05 | 2021-04-06 | 36 | 0d |  |  | 24 Horas |
| 38 | 1.4.2.19 | Desmontagem 7 |  | 48h | 2021-04-06 | 2021-04-08 | 37 | 0d |  |  | 24 Horas |
| 39 | 1.4.2.20 | montagem 7 |  | 72h | 2021-04-08 | 2021-04-11 | 38 | 0d |  |  | 24 Horas |
| 40 | 1.4.2.21 | Testes e liberação 7 |  | 24h | 2021-04-11 | 2021-04-12 | 39 | 0d |  |  | 24 Horas |
| 41 | 1.4.2.22 | Desmontagem 8 |  | 48h | 2021-04-12 | 2021-04-14 | 40 | 0d |  |  | 24 Horas |
| 42 | 1.4.2.23 | montagem 8 |  | 72h | 2021-04-14 | 2021-04-17 | 41 | 0d |  |  | 24 Horas |
| 43 | 1.4.2.24 | Testes e liberação 8 |  | 24h | 2021-04-17 | 2021-04-18 | 42 | 0d |  |  | 24 Horas |
| 44 | 1.4.2.25 | Encerramento da Obra | milestone | 0d | 2021-04-18 | 2021-04-18 | 43 | 0d |  |  | 24 Horas |

| ID | WBS | Task | Type | Duration | Start | Finish | Predecessors | Total slack | Calendar |
| --- | --- | --- | --- | --- | --- | --- | --- | --- | --- |
| 45 | 1.5 | **Operação Assistida** |  | 21.12d | 2021-04-18 | 2021-05-18 |  | 0d |  |
| 46 | 1.5.1 | Fase de Operação Assistida |  | 720h | 2021-04-18 | 2021-05-18 | 44 | 0d | 24 Horas |
| 47 | 1.6 | Encerramento do Objeto | milestone | 0d | 2021-05-18 | 2021-05-18 | 46 | 0d | 24 Horas |
